Schedule from MS Project, 2025-06-16 to 2026-02-06, 9 hours a day.
Microsoft

## Calendars

- Стандартный: Mon-Fri 09:00-13:00, 14:00-18:00; Sat-Sun off.

## Schedule

| ID | WBS | Task | Duration | Start | Finish | Predecessors | Total slack | Free slack | Constraint |
| --- | --- | --- | --- | --- | --- | --- | --- | --- | --- |
| 1 | 1 | **Усть-Луга АБК, РММ, КПП-2 ОВ, ВК, АОВ, ТМ** | 150d | 2025-06-16 | 2026-02-06 |  |  |  |  |
| 2 | 1.1 | **РММ** | 103d | 2025-06-16 | 2025-11-25 |  |  |  |  |
| 3 | 1.1.1 | Монтаж магистральных трубопроводов отопления, теплоснабжения вентиляции, завес | 60d | 2025-06-16 | 2025-09-17 |  | 53d | 6.33d | finish no earlier than 2025-09-17 |
| 4 | 1.1.2 | Монтаж и обвязка радиаторов, тепловентиляторов, завес | 57d | 2025-08-04 | 2025-11-01 | 3FS-38d | 61.56d | 15.67d | finish no earlier than 2025-11-01 |
| 5 | 1.1.3 | Монтаж смесительных узлов теплоснабжения в венткамерах | 31d | 2025-09-16 | 2025-11-03 | 3FS-8d | 60.67d |  | finish no earlier than 2025-11-03 |
| 6 | 1.1.4 | Заказ и поставка дымовых люков | 18d | 2025-07-01 | 2025-07-29 |  | 119.11d |  | finish no earlier than 2025-07-29 |
| 7 | 1.1.5 | Монтаж дымовых люков с системой управления | 20d | 2025-08-01 | 2025-09-02 | 6 | 56.78d | 8.89d | finish no earlier than 2025-09-02 |
| 8 | 1.1.6 | Монтаж воздуховодов, воздухораспределителей систем вентиляции по помещениям | 63d | 2025-06-25 | 2025-10-01 |  | 55.11d | 4.44d | finish no earlier than 2025-10-01 |
| 9 | 1.1.7 | Монтаж и обвязка вентоборудования в венткамерах | 39d | 2025-08-01 | 2025-10-01 | 8FS-68d | 51.11d | 3.22d | finish no earlier than 2025-10-01 |
| 10 | 1.1.8 | Заказ и поставка оборудования кондиционирования | 22d | 2025-06-23 | 2025-07-27 |  | 120.89d |  | finish no earlier than 2025-07-27 |
| 11 | 1.1.9 | Монтаж системы кондиционирования | 46d | 2025-07-28 | 2025-10-07 | 10, 8FS-70d | 77.78d |  | finish no earlier than 2025-10-01 |
| 12 | 1.1.10 | Монтаж трубопроводов водоснабжения | 57d | 2025-07-02 | 2025-09-30 |  | 79.11d |  | finish no earlier than 2025-09-30 |
| 13 | 1.1.11 | Монтаж шкафов противопожарного водопровода | 20d | 2025-10-01 | 2025-10-31 | 12 | 61.56d |  | finish no earlier than 2025-10-31 |
| 14 | 1.1.12 | Монтаж ливневой канализации К2 | 55d | 2025-07-01 | 2025-09-24 |  | 82.67d |  | finish no earlier than 2025-09-24 |
| 15 | 1.1.13 | Монтаж систем канализации К1, К3, К4 | 79d | 2025-07-01 | 2025-10-31 | 14SS | 71.56d |  | finish no earlier than 2025-10-31 |
| 16 | 1.1.14 | Монтаж тепломеханики, автоматики ИТП | 36d | 2025-07-22 | 2025-09-16 | 3FS-44d | 47.89d | 0d | finish no earlier than 2025-09-16 |
| 17 | 1.1.15 | Монтаж автоматики вентиляции | 24d | 2025-10-09 | 2025-11-15 | 8 | 52.67d |  | finish no earlier than 2025-11-15 |
| 18 | 1.1.16 | Пуско-наладочные работы отопления, теплоснабжения завес, тепловентиляторов, вентиляции, ИТП | 43d | 2025-09-17 | 2025-11-24 | 16, 4FS-45d, 7, 9FS-13d | 47.89d |  | finish no earlier than 2025-11-21 |
| 19 | 1.2 | **АБК** | 144d | 2025-06-23 | 2026-02-04 |  |  |  |  |
| 20 | 1.2.1 | Монтаж трубопроводов отопления, теплоснабжения вентиляции | 63d | 2025-06-24 | 2025-09-30 |  | 34d | 0d | finish no earlier than 2025-09-30 |
| 21 | 1.2.2 | Монтаж и обвязка радиаторов | 58d | 2025-08-01 | 2025-10-31 | 20FS-60d | 61.56d | 38.33d | finish no earlier than 2025-10-31 |
| 22 | 1.2.3 | Монтаж воздуховодов, воздухораспределителей систем вентиляции по помещениям | 102d | 2025-06-23 | 2025-11-30 |  | 19.78d | 0.78d | finish no earlier than 2025-11-30 |
| 23 | 1.2.4 | Монтаж смесительных узлов теплоснабжения в венткамерах | 27d | 2025-11-03 | 2025-12-15 | 22FS-18d | 24d | 5.11d | finish no earlier than 2025-12-15 |
| 24 | 1.2.5 | Монтаж и обвязка вентоборудования в венткамерах | 59d | 2025-09-01 | 2025-12-02 | 22FS-65d | 2d | 0d | finish no earlier than 2025-12-02 |
| 25 | 1.2.6 | Монтаж системы кондиционирования | 93d | 2025-07-22 | 2025-12-15 |  | 44d |  | finish no earlier than 2025-12-15 |
| 26 | 1.2.7 | Заказ и поставка ёмкостей для водоснабжения | 20d | 2025-07-01 | 2025-07-31 |  | 45.22d | 0.33d | finish no earlier than 2025-07-31 |
| 27 | 1.2.8 | Монтаж ливневой канализации К2 | 55d | 2025-07-01 | 2025-09-24 |  | 95.56d |  | finish no earlier than 2025-09-24 |
| 28 | 1.2.9 | Монтаж трубопроводов водоснабжения, канализации К1, К3 | 85d | 2025-08-01 | 2025-12-14 | 26 | 34.89d | 3.56d | finish no earlier than 2025-12-14 |
| 29 | 1.2.10 | Монтаж шкафов противопожарного водопровода | 17d | 2025-11-10 | 2025-12-07 | 28FS-25d | 39.33d |  | finish no earlier than 2025-12-07 |
| 30 | 1.2.11 | Монтаж автоматики вентиляции | 58d | 2025-10-08 | 2026-01-07 | 23FS-48d | 18.89d |  | finish no earlier than 2026-01-07 |
| 31 | 1.2.12 | Пуско-наладочные работы отопления | 44d | 2025-09-15 | 2025-11-21 | 21FS-69d | 48.22d |  | finish no earlier than 2025-11-21 |
| 32 | 1.2.13 | Пуско-наладочные работы вентиляции, теплоснабжения, автоматизации вентиляции | 40d | 2025-12-03 | 2026-02-03 | 24 | 2d |  | finish no earlier than 2026-02-02 |

| ID | WBS | Task | Duration | Start | Finish | Predecessors | Total slack | Free slack | Constraint |
| --- | --- | --- | --- | --- | --- | --- | --- | --- | --- |
| 33 | 1.3 | **КПП-2** | 54d | 2025-08-01 | 2025-10-27 |  |  |  |  |
| 34 | 1.3.1 | Монтаж системы отопления | 18d | 2025-08-01 | 2025-08-31 |  | 102.56d | 26.67d | finish no earlier than 2025-08-31 |
| 35 | 1.3.2 | Монтаж системы вентиляции | 18d | 2025-09-01 | 2025-09-29 |  | 83.89d | 8d | finish no earlier than 2025-09-29 |
| 36 | 1.3.3 | Монтаж систем водоснабжения, водоотведения | 17d | 2025-09-15 | 2025-10-11 |  | 75.89d | 0d | finish no earlier than 2025-10-11 |
| 37 | 1.3.4 | Пуско-наладочные работы | 9d | 2025-10-13 | 2025-10-27 | 36, 34, 35 | 65.89d |  | finish no earlier than 2025-10-24 |
